# Exercise_03_01

Schedule from MS Project, 2014-11-10 to 2014-12-25, costs in р..

## Calendars

- Стандартный: Mon-Fri 09:00-13:00, 14:00-18:00; Sat-Sun off.

## Resources

| Resource | Unit | Rate |
| --- | --- | --- |
| Иванов |  | 156.25 |
| Корректор |  | 150 |
| Бумага | пачка | 100 |
| Типография |  |  |
| Петров |  | 125 |
| Степанов |  | 62.5 |
| Федоров |  | 100 |
| Сергеев |  | 62.5 |
| Художник |  |  |

## Schedule

| ID | WBS | Task | Duration | Start | Finish | Predecessors | Baseline start | Baseline finish | Baseline duration | Baseline 1 start | Baseline 1 finish | Total slack | Free slack | Constraint | Resources | Work | Cost |
| --- | --- | --- | --- | --- | --- | --- | --- | --- | --- | --- | --- | --- | --- | --- | --- | --- | --- |
| 1 | 1 | **Заседание редсовета** | 25.25d | 2014-11-10 08:00 | 2014-12-15 11:00 |  | 2014-11-10 09:00 | 2014-12-15 12:00 | 25.38d | 2014-11-10 08:00 | 2014-12-01 11:00 | 7.75d |  |  |  | 14h | 1,937.5 |
| 2 | 1.1 | Заседание редсовета 1 | 2h | 2014-11-10 08:00 | 2014-11-10 11:00 |  | 2014-11-10 09:00 | 2014-11-10 15:00 | 5h | 2014-11-10 08:00 | 2014-11-10 11:00 | 32.75d |  | start no earlier than 2014-11-10 08:00 | Иванов; Петров | 2h | 250 |
| 3 | 1.2 | Заседание редсовета 2 | 2h | 2014-11-17 09:00 | 2014-11-17 11:00 |  | 2014-11-17 09:00 | 2014-11-17 12:00 | 3h | 2014-11-17 09:00 | 2014-11-17 11:00 | 27.75d |  | start no earlier than 2014-11-17 08:00 | Иванов; Петров | 4h | 562.5 |
| 4 | 1.3 | Заседание редсовета 3 | 2h | 2014-11-24 09:00 | 2014-11-24 11:00 |  | 2014-11-24 09:00 | 2014-11-24 12:00 | 3h | 2014-11-24 09:00 | 2014-11-24 11:00 | 22.75d |  | start no earlier than 2014-11-24 08:00 | Иванов; Петров | 4h | 562.5 |
| 5 | 1.4 | Заседание редсовета 4 | 2h | 2014-12-01 09:00 | 2014-12-01 11:00 |  | 2014-12-01 09:00 | 2014-12-01 12:00 | 3h | 2014-12-01 09:00 | 2014-12-01 11:00 | 17.75d |  | start no earlier than 2014-12-01 08:00 | Иванов; Петров | 4h | 562.5 |
| 6 | 1.5 | Заседание редсовета 5 | 2h | 2014-12-08 09:00 | 2014-12-08 11:00 |  |  |  |  |  |  | 12.75d |  | start no earlier than 2014-12-08 08:00 |  |  |  |
| 7 | 1.6 | Заседание редсовета 6 | 2h | 2014-12-15 09:00 | 2014-12-15 11:00 |  |  |  |  |  |  | 7.75d |  | start no earlier than 2014-12-15 08:00 |  |  |  |
| 8 | 2 | **Редактирование** | 23.25d | 2014-11-10 09:00 | 2014-12-11 11:00 |  | 2014-11-10 09:00 | 2014-12-11 11:00 | 23.25d | 2014-11-10 09:00 | 2014-12-18 11:49 | 0d |  |  |  | 518.83h | 55,003.91 |
| 9 | 2.1 | Ред_Раздел 1 | 14.6d | 2014-11-17 11:00 | 2014-12-08 11:49 |  | 2014-11-10 09:00 | 2014-11-28 14:49 | 14.6d | 2014-11-17 11:00 | 2014-12-08 11:49 | 1.42d | 0d |  | Иванов | 116.83h | 18,253.91 |
| 10 | 2.2 | Ред_Раздел 2 | 8d | 2014-11-10 11:00 | 2014-11-20 13:00 |  | 2014-11-10 09:00 | 2014-11-19 18:00 | 8d | 2014-12-08 11:49 | 2014-12-18 11:49 | 16.77d | 0d |  | Петров | 64h | 8,000 |
| 11 | 2.3 | Ред_Раздел 3 | 12d | 2014-11-10 10:00 | 2014-12-10 17:00 |  | 2014-11-10 09:00 | 2014-11-25 18:00 | 12d | 2014-11-10 10:00 | 2014-12-10 17:00 | 2.88d | 0d |  | Степанов | 96h | 6,000 |
| 12 | 2.4 | Ред_Раздел 4 | 7d | 2014-11-20 14:00 | 2014-12-01 16:00 |  | 2014-11-10 09:00 | 2014-11-18 18:00 | 7d | 2014-11-10 09:00 | 2014-11-19 11:00 | 9.52d | 0d |  | Петров | 56h | 7,000 |
| 13 | 2.5 | Ред_Раздел 5 | 23.25d | 2014-11-10 09:00 | 2014-12-11 11:00 |  | 2014-11-10 09:00 | 2014-12-11 11:00 | 23.25d | 2014-11-10 09:00 | 2014-12-11 11:00 | 0d |  |  | Сергеев | 186h | 15,750 |
| 14 | 3 | **Корректура** | 19.27d | 2014-11-20 14:00 | 2014-12-17 16:10 |  | 2014-11-19 09:00 | 2014-12-16 11:00 | 19.25d | 2014-11-19 11:00 | 2014-12-22 16:49 | 0d |  |  |  | 104h | 15,600 |
| 15 | 3.1 | Корр_Раздел 1 | 3d | 2014-12-11 11:49 | 2014-12-16 11:49 | 9FS+3d | 2014-11-28 14:49 | 2014-12-03 14:49 | 3d | 2014-12-11 11:49 | 2014-12-16 11:49 | 1.42d |  |  | Корректор | 24h | 3,600 |
| 16 | 3.2 | Корр_Раздел 2 | 2.5d | 2014-11-20 14:00 | 2014-11-24 18:00 | 10 | 2014-11-20 09:00 | 2014-11-24 13:00 | 2.5d | 2014-12-18 11:49 | 2014-12-22 16:49 | 16.77d |  |  | Корректор | 20h | 3,000 |
| 17 | 3.3 | Корр_Раздел 3 | 2d | 2014-12-10 17:00 | 2014-12-12 17:00 | 11 | 2014-11-26 09:00 | 2014-11-27 18:00 | 2d | 2014-12-10 17:00 | 2014-12-12 17:00 | 2.9d |  |  | Корректор | 16h | 2,400 |
| 18 | 3.4 | Корр_Раздел 4 | 2.5d | 2014-12-01 16:00 | 2014-12-04 11:00 | 12 | 2014-11-19 09:00 | 2014-11-21 13:00 | 2.5d | 2014-11-19 11:00 | 2014-11-21 16:00 | 9.52d |  |  | Корректор | 20h | 3,000 |
| 19 | 3.5 | Корр_Раздел 5 | 3d | 2014-12-11 11:00 | 2014-12-17 16:10 | 13 | 2014-12-11 11:00 | 2014-12-16 11:00 | 3d | 2014-12-11 11:00 | 2014-12-17 16:10 | 0d |  |  | Корректор | 24h | 3,600 |
| 20 | 4 | Верстка | 3d | 2014-12-17 16:10 | 2014-12-22 16:10 | 14 | 2014-12-16 11:00 | 2014-12-19 11:00 | 3d | 2014-12-22 16:49 | 2014-12-25 16:49 | 2d |  |  | Сергеев | 24h | 3,000 |
| 21 | 5 | Обложка | 5d | 2014-12-17 16:10 | 2014-12-24 16:10 | 14 | 2014-12-19 11:00 | 2014-12-26 11:00 | 5d | 2014-12-25 16:49 | 2015-01-01 16:49 | 0d |  |  | Художник [0.1%] |  | 5,000 |
| 22 | 6 | Печать | 2d | 2014-12-24 16:10 | 2014-12-25 08:10 | 21, 20 | 2014-12-26 11:00 | 2014-12-30 11:00 | 2d | 2015-01-01 16:49 | 2015-01-02 08:49 | 0d |  |  | Типография | 16h |  |
