# Exercise_03_01

Schedule from MS Project, 2014-11-10 to 2015-03-20, costs in р..

## Calendars

- Стандартный: Mon-Fri 09:00-13:00, 14:00-18:00; Sat-Sun off. Exceptions (off unless hours are given): 2014-12-31 to 2015-01-11 (Новый год), 2015-02-24 (ДЗО), 2015-03-09 (МЖД).

## Resources

| Resource | Unit | Rate |
| --- | --- | --- |
| Иванов |  | 156.25 |
| Корректор |  | 150 |
| Бумага | пачка | 100 |
| Типография |  |  |
| Петров |  | 125 |
| Степанов |  | 62.5 |
| Федоров |  | 100 |
| Сергеев |  | 62.5 |
| Художник |  |  |

## Schedule

| ID | WBS | Task | Duration | Start | Finish | Predecessors | Total slack | Free slack | Constraint | Resources | Work | Cost |
| --- | --- | --- | --- | --- | --- | --- | --- | --- | --- | --- | --- | --- |
| 1 | 1 | **Заседание редсовета** | 25.25d | 2014-11-10 08:00 | 2014-12-15 11:00 |  | 59.23d |  |  |  | 20h | 2,687.5 |
| 2 | 1.1 | Заседание редсовета 1 | 2h | 2014-11-10 08:00 | 2014-11-10 11:00 |  | 85.23d | 57.5d | start no earlier than 2014-11-10 08:00 | Иванов; Петров | 2h | 250 |
| 3 | 1.2 | Заседание редсовета 2 | 2h | 2014-11-17 08:00 | 2014-11-17 11:00 |  | 80.23d | 52.5d | start no earlier than 2014-11-17 08:00 | Иванов; Петров; Степанов | 2h | 187.5 |
| 4 | 1.3 | Заседание редсовета 3 | 2h | 2014-11-24 09:00 | 2014-11-24 11:00 |  | 75.23d | 47.5d | start no earlier than 2014-11-24 08:00 | Иванов; Петров | 4h | 562.5 |
| 5 | 1.4 | Заседание редсовета 4 | 2h | 2014-12-01 09:00 | 2014-12-01 11:00 |  | 70.23d | 42.5d | start no earlier than 2014-12-01 08:00 | Иванов; Петров | 4h | 562.5 |
| 6 | 1.5 | Заседание редсовета 5 | 2h | 2014-12-08 09:00 | 2014-12-08 11:00 |  | 65.23d | 37.5d | start no earlier than 2014-12-08 08:00 | Иванов; Петров | 4h | 562.5 |
| 7 | 1.6 | Заседание редсовета 6 | 2h | 2014-12-15 09:00 | 2014-12-15 11:00 |  | 60.23d | 32.5d | start no earlier than 2014-12-15 08:00 | Иванов; Петров | 4h | 562.5 |
| 8 | 2 | **Редактирование** | 71.35d | 2014-11-10 10:00 | 2015-03-02 12:49 |  | 1d |  |  | Федоров [50%] | 804.24h | 76,217.81 |
| 9 | 2.1 | Ред_Раздел 1 | 14.6d | 2014-11-10 10:00 | 2014-12-17 17:49 |  | 43.5d | 0d |  | Степанов | 116.83h | 7,301.56 |
| 10 | 2.2 | Ред_Раздел 2 | 8d | 2014-11-10 11:00 | 2014-11-20 12:00 |  | 64.6d | 0d |  | Петров | 64h | 8,000 |
| 11 | 2.3 | Ред_Раздел 3 | 12d | 2014-11-20 12:00 | 2014-12-09 10:00 |  | 52.35d | 0d |  | Петров | 96h | 12,000 |
| 12 | 2.4 | Ред_Раздел 4 | 7d | 2014-11-17 09:00 | 2014-11-26 11:00 |  | 59.73d | 0d |  | Иванов | 56h | 8,750 |
| 13 | 2.5 | Ред_Раздел 5 | 23.25d | 2014-12-17 17:49 | 2015-03-02 12:49 |  | 0d |  |  | Степанов | 186h | 11,625 |
| 14 | 3 | **Корректура** | 66.1d | 2014-11-20 12:00 | 2015-03-05 12:49 |  | 0d |  |  | Федоров [50%] | 368.41h | 42,041.25 |
| 15 | 3.1 | Корр_Раздел 1 | 3d | 2014-12-17 17:49 | 2014-12-22 17:49 | 9 | 44.5d |  |  | Корректор | 24h | 3,600 |
| 16 | 3.2 | Корр_Раздел 2 | 2.5d | 2014-11-20 12:00 | 2014-11-24 17:00 | 10 | 64.6d |  |  | Корректор | 20h | 3,000 |
| 17 | 3.3 | Корр_Раздел 3 | 2d | 2014-12-09 10:00 | 2014-12-11 10:00 | 11 | 52.35d |  |  | Корректор | 16h | 2,400 |
| 18 | 3.4 | Корр_Раздел 4 | 2.5d | 2014-11-26 11:00 | 2014-11-28 16:00 | 12 | 60.73d |  |  | Корректор | 20h | 3,000 |
| 19 | 3.5 | Корр_Раздел 5 | 3d | 2015-03-02 12:49 | 2015-03-05 12:49 | 13 | 0d |  |  | Корректор | 24h | 3,600 |
| 20 | 4 | Верстка | 3d | 2015-03-05 12:49 | 2015-03-11 12:49 | 14 | 0d |  |  | Сергеев | 24h | 3,000 |
| 21 | 5 | Обложка | 5d | 2015-03-11 12:49 | 2015-03-18 12:49 | 20 | 0d |  |  | Художник [0.1%]; Федоров | 40h | 9,000 |
| 22 | 6 | Печать | 3.48d | 2015-03-18 12:49 | 2015-03-20 12:49 | 21 | 0d |  |  | Типография; Федоров | 32h | 1,600 |
