# Exercise_03_01

Schedule from MS Project, 2014-11-10 to 2015-03-02, costs in р..

## Calendars

- Стандартный: Mon-Fri 09:00-13:00, 14:00-18:00; Sat-Sun off. Exceptions (off unless hours are given): 2014-12-31 to 2015-01-11 (Новый год), 2015-02-24 (ДЗО).

## Resources

| Resource | Unit | Rate |
| --- | --- | --- |
| Иванов |  | 156.25 |
| Корректор |  | 150 |
| Бумага писчая | пачка | 100 |
| Типография |  |  |
| Петров |  | 125 |
| Степанов |  | 62.5 |
| Федоров |  | 100 |
| Сергеев |  | 62.5 |
| Художник |  |  |
| Бумага типографская | п.л. | 20 |
| Транспорт |  |  |
| Почтовые расходы |  |  |

## Schedule

| ID | WBS | Task | Duration | Start | Finish | Predecessors | Baseline start | Baseline finish | Baseline duration | Total slack | Free slack | Resources | Work | Cost | Baseline cost |
| --- | --- | --- | --- | --- | --- | --- | --- | --- | --- | --- | --- | --- | --- | --- | --- |
| 1 | 1 | **Редактирование** | 52d | 2014-11-10 | 2015-01-30 |  | 2014-11-10 | 2015-01-30 | 52d | 2d |  | Федоров [50%] | 1000h | 107,800 | 107,800 |
| 2 | 1.1 | Ред_Раздел 1 | 11d | 2014-11-17 | 2014-12-01 |  | 2014-11-17 | 2014-12-01 | 11d | 34.66d | 0d | Сергеев | 88h | 6,000 | 6,000 |
| 3 | 1.2 | Ред_Раздел 2 | 8d | 2014-11-10 | 2014-11-19 |  | 2014-11-10 | 2014-11-19 | 8d | 43.66d | 0d | Петров | 64h | 8,000 | 8,000 |
| 4 | 1.3 | Ред_Раздел 3 | 12d | 2014-12-01 | 2014-12-16 |  | 2014-12-01 | 2014-12-16 | 12d | 23.33d | 0d | Иванов | 96h | 15,000 | 15,000 |
| 5 | 1.4 | Ред_Раздел 4 | 3d | 2014-11-26 | 2014-12-10 |  | 2014-11-26 | 2014-12-10 | 3d | 30.33d | 0d | Петров | 24h | 3,000 | 3,000 |
| 6 | 1.5 | Ред_Раздел 5 | 15d | 2014-11-10 | 2014-11-28 |  | 2014-11-10 | 2014-11-28 | 15d | 32.66d | 0d | Иванов | 120h | 18,750 | 18,750 |
| 7 | 1.6 | Ред_Статья 6 | 4d | 2014-12-24 | 2014-12-29 |  | 2014-12-24 | 2014-12-29 | 4d | 17d | 0d | Иванов | 32h | 5,000 | 5,000 |
| 8 | 1.7 | Ред_Статья 7 | 5d | 2014-12-17 | 2014-12-23 |  | 2014-12-17 | 2014-12-23 | 5d | 20.66d | 0d | Иванов | 40h | 6,250 | 6,250 |
| 9 | 1.8 | Ред_Статья 8 | 2d | 2014-12-02 | 2014-12-03 |  | 2014-12-02 | 2014-12-03 | 2d | 35.66d | 0d | Сергеев | 16h | 2,000 | 2,000 |
| 10 | 1.9 | Ред_Статья 9 | 1d | 2014-12-02 | 2014-12-02 |  | 2014-12-02 | 2014-12-02 | 1d | 37d | 0d | Петров | 8h | 1,000 | 1,000 |
| 11 | 1.10 | Ред_Статья 10 | 4d | 2014-11-20 | 2014-11-25 |  | 2014-11-20 | 2014-11-25 | 4d | 41d | 0d | Петров | 32h | 4,000 | 4,000 |
| 12 | 1.11 | Ред_Раздел 11 | 2d | 2014-11-28 | 2014-12-01 |  | 2014-11-28 | 2014-12-01 | 2d | 37.66d | 0d | Петров | 16h | 2,000 | 2,000 |
| 13 | 1.12 | Ред_Раздел 12 | 5d | 2014-11-10 | 2014-11-14 |  | 2014-11-10 | 2014-11-14 | 5d | 47.66d | 0d | Сергеев | 40h | 2,500 | 2,500 |
| 14 | 1.13 | Ред_Раздел 13 | 7d | 2015-01-12 | 2015-01-30 |  | 2015-01-12 | 2015-01-30 | 7d | 0d |  | Степанов | 56h | 3,500 | 3,500 |
| 15 | 1.14 | Ред_Раздел 14 | 11d | 2014-11-10 | 2014-12-08 |  | 2014-11-10 | 2014-12-08 | 11d | 29.25d | 0d | Степанов | 88h | 5,500 | 5,500 |
| 16 | 1.15 | Ред_Раздел 15 | 9d | 2014-12-08 | 2015-01-12 |  | 2014-12-08 | 2015-01-12 | 9d | 12.25d | 0d | Степанов | 72h | 4,500 | 4,500 |
| 17 | 2 | **Корректура** | 49.33d | 2014-11-17 | 2015-02-04 |  | 2014-11-17 | 2015-02-04 | 49.33d | 0d |  |  | 264.08h | 39,612 | 39,612 |
| 18 | 2.1 | Корр_Статья 1 | 3.67d | 2014-12-02 | 2014-12-05 | 2 | 2014-12-02 | 2014-12-05 | 3.67d | 34.66d |  | Корректор | 29.36h | 4,404 | 4,404 |
| 19 | 2.2 | Корр_Статья 2 | 2.67d | 2014-11-20 | 2014-11-24 | 3 | 2014-11-20 | 2014-11-24 | 2.67d | 43.66d |  | Корректор | 21.36h | 3,204 | 3,204 |
| 20 | 2.3 | Корр_Статья 3 | 4d | 2014-12-17 | 2014-12-22 | 4 | 2014-12-17 | 2014-12-22 | 4d | 23.33d |  | Корректор | 32h | 4,800 | 4,800 |
| 21 | 2.4 | Корр_Статья 4 | 1d | 2014-12-11 | 2014-12-11 | 5 | 2014-12-11 | 2014-12-11 | 1d | 30.33d |  | Корректор | 8h | 1,200 | 1,200 |
| 22 | 2.5 | Корр_Статья 5 | 5d | 2014-12-01 | 2014-12-09 | 6 | 2014-12-01 | 2014-12-09 | 5d | 32.66d |  | Корректор | 40h | 6,000 | 6,000 |
| 23 | 2.6 | Корр_Статья 6 | 1.33d | 2014-12-30 | 2015-01-12 | 7 | 2014-12-30 | 2015-01-12 | 1.33d | 17d |  | Корректор | 10.64h | 1,596 | 1,596 |
| 24 | 2.7 | Корр_Статья 7 | 1.67d | 2014-12-24 | 2014-12-25 | 8 | 2014-12-24 | 2014-12-25 | 1.67d | 20.66d |  | Корректор | 13.36h | 2,004 | 2,004 |
| 25 | 2.8 | Корр_Статья 8 | 0.67d | 2014-12-04 | 2014-12-04 | 9 | 2014-12-04 | 2014-12-04 | 0.67d | 35.66d |  | Корректор | 5.36h | 804 | 804 |
| 26 | 2.9 | Корр_Статья 9 | 0.33d | 2014-12-03 | 2014-12-03 | 10 | 2014-12-03 | 2014-12-03 | 0.33d | 37d |  | Корректор | 2.64h | 396 | 396 |
| 27 | 2.10 | Корр_Статья 10 | 1.33d | 2014-11-26 | 2014-11-27 | 11 | 2014-11-26 | 2014-11-27 | 1.33d | 41d |  | Корректор | 10.64h | 1,596 | 1,596 |
| 28 | 2.11 | Корр_Статья 11 | 0.67d | 2014-12-02 | 2014-12-02 | 12 | 2014-12-02 | 2014-12-02 | 0.67d | 37.66d |  | Корректор | 5.36h | 804 | 804 |
| 29 | 2.12 | Корр_Статья 12 | 1.67d | 2014-11-17 | 2014-11-18 | 13 | 2014-11-17 | 2014-11-18 | 1.67d | 47.66d |  | Корректор | 13.36h | 2,004 | 2,004 |
| 30 | 2.13 | Корр_Статья 13 | 2.33d | 2015-02-02 | 2015-02-04 | 14 | 2015-02-02 | 2015-02-04 | 2.33d | 0d |  | Корректор | 18.64h | 2,796 | 2,796 |
| 31 | 2.14 | Корр_Статья 14 | 3.67d | 2014-12-08 | 2014-12-12 | 15 | 2014-12-08 | 2014-12-12 | 3.67d | 29.91d |  | Корректор | 29.36h | 4,404 | 4,404 |
| 32 | 2.15 | Корр_Статья 15 | 3d | 2015-01-13 | 2015-01-15 | 16 | 2015-01-13 | 2015-01-15 | 3d | 13.33d |  | Корректор | 24h | 3,600 | 3,600 |
| 33 | 3 | Верстка | 11d | 2015-02-04 | 2015-02-19 | 17 | 2015-02-04 | 2015-02-19 | 11d | 0d |  | Сергеев | 88h | 11,000 | 11,000 |
| 34 | 4 | Обложка | 6d | 2015-02-02 | 2015-02-09 |  | 2015-02-02 | 2015-02-09 | 6d | 13.33d |  | Художник [0.1%]; Федоров; Почтовые расходы [0.1%] | 48h | 10,800 | 10,800 |
| 35 | 5 | Печать | 6d | 2015-02-19 | 2015-03-02 | 33 | 2015-02-19 | 2015-03-02 | 6d | 0d |  | Типография; Федоров [50%]; Бумага типографская [1200 п.л.]; Почтовые расходы [0.1%] | 8h | 25,800 | 25,800 |
