# Exercise_03_01

Schedule from MS Project, 2014-11-10 to 2015-03-02, costs in р..

## Calendars

- Стандартный: Mon-Fri 09:00-13:00, 14:00-18:00; Sat-Sun off. Exceptions (off unless hours are given): 2014-12-31 to 2015-01-11 (Новый год), 2015-02-24 (ДЗО).

## Resources

| Resource | Unit | Rate |
| --- | --- | --- |
| Иванов |  | 156.25 |
| Корректор |  | 150 |
| Бумага писчая | пачка | 100 |
| Типография |  |  |
| Петров |  | 125 |
| Степанов |  | 62.5 |
| Федоров |  | 100 |
| Сергеев |  | 62.5 |
| Художник |  |  |
| Бумага типографская | пачка | 100 |
| Транспорт |  |  |
| Почтовые расходы |  |  |

## Schedule

| ID | WBS | Task | Duration | Start | Finish | Predecessors | Baseline start | Baseline finish | Baseline duration | Total slack | Free slack | Resources | Work | Cost | Baseline cost |
| --- | --- | --- | --- | --- | --- | --- | --- | --- | --- | --- | --- | --- | --- | --- | --- |
| 1 | 1 | **Редактирование** | 52d | 2014-11-10 | 2015-01-30 |  | 2014-11-10 | 2015-01-19 | 51d | 2d | 0d | Федоров [50%] | 1000h | 109,300 | 107,400 |
| 2 | 1.1 | Ред_Раздел 1 | 11d | 2014-11-17 | 2014-12-01 |  | 2014-11-17 | 2014-12-02 | 11d | 34.66d | 0d | Сергеев; Бумага писчая [1 пачка] | 88h | 6,100 | 6,187.5 |
| 3 | 1.2 | Ред_Раздел 2 | 8d | 2014-11-10 | 2014-11-19 |  | 2014-11-12 | 2014-11-21 | 8d | 43.66d | 0d | Петров; Бумага писчая [1 пачка] | 64h | 8,100 | 8,000 |
| 4 | 1.3 | Ред_Раздел 3 | 12d | 2014-12-01 | 2014-12-16 |  | 2014-12-01 | 2014-12-16 | 12d | 23.33d | 0d | Иванов; Бумага писчая [1 пачка] | 96h | 15,100 | 15,000 |
| 5 | 1.4 | Ред_Раздел 4 | 3d | 2014-11-26 | 2014-12-10 |  | 2014-11-10 | 2014-11-24 | 3d | 30.33d | 0d | Петров; Бумага писчая [1 пачка] | 24h | 3,100 | 3,000 |
| 6 | 1.5 | Ред_Раздел 5 | 15d | 2014-11-10 | 2014-11-28 |  | 2014-11-10 | 2014-11-28 | 15d | 30.99d | 0d | Иванов; Бумага писчая [1 пачка] | 120h | 18,850 | 18,750 |
| 7 | 1.6 | Ред_Статья 6 | 4d | 2014-12-24 | 2014-12-29 |  | 2014-12-24 | 2014-12-29 | 4d | 17d | 0d | Иванов; Бумага писчая [1 пачка] | 32h | 5,100 | 5,000 |
| 8 | 1.7 | Ред_Статья 7 | 5d | 2014-12-17 | 2014-12-23 |  | 2014-12-17 | 2014-12-23 | 5d | 20.66d | 0d | Иванов; Бумага писчая [1 пачка] | 40h | 6,350 | 6,250 |
| 9 | 1.8 | Ред_Статья 8 | 2d | 2014-12-02 | 2014-12-03 |  | 2014-11-19 | 2014-12-03 | 2d | 35.66d | 0d | Сергеев; Бумага писчая [1 пачка] | 16h | 2,100 | 1,812.5 |
| 10 | 1.9 | Ред_Статья 9 | 1d | 2014-12-02 | 2014-12-02 |  | 2014-12-03 | 2014-12-03 | 1d | 37d | 0d | Петров; Бумага писчая [1 пачка] | 8h | 1,100 | 1,000 |
| 11 | 1.10 | Ред_Статья 10 | 4d | 2014-11-20 | 2014-11-25 |  | 2014-11-25 | 2014-11-28 | 4d | 41d | 0d | Петров; Бумага писчая [1 пачка] | 32h | 4,100 | 4,000 |
| 12 | 1.11 | Ред_Раздел 11 | 2d | 2014-11-28 | 2014-12-01 |  | 2014-12-01 | 2014-12-02 | 2d | 37.66d | 0d | Петров; Бумага писчая [1 пачка] | 16h | 2,100 | 2,000 |
| 13 | 1.12 | Ред_Раздел 12 | 5d | 2014-11-10 | 2014-11-14 |  | 2014-11-10 | 2014-11-14 | 5d | 47.66d | 0d | Сергеев; Бумага писчая [1 пачка] | 40h | 2,600 | 2,500 |
| 14 | 1.13 | Ред_Раздел 13 | 7d | 2015-01-12 | 2015-01-30 |  | 2014-12-31 | 2015-01-19 | 7d | 0d |  | Степанов; Бумага писчая [1 пачка] | 56h | 3,600 | 3,500 |
| 15 | 1.14 | Ред_Раздел 14 | 11d | 2014-11-10 | 2014-12-08 |  | 2014-11-10 | 2014-12-08 | 11d | 29.25d | 0d | Степанов; Бумага писчая [1 пачка] | 88h | 5,600 | 5,500 |
| 16 | 1.15 | Ред_Раздел 15 | 9d | 2014-12-08 | 2015-01-12 |  | 2014-12-08 | 2014-12-31 | 9d | 12.25d | 0d | Степанов; Бумага писчая [1 пачка] | 72h | 4,600 | 4,500 |
| 17 | 2 | **Корректура** | 49.33d | 2014-11-17 | 2015-02-04 |  |  |  |  | 0d |  |  | 264.08h | 41,112 |  |
| 18 | 2.1 | Корр_Статья 1 | 3.67d | 2014-12-02 | 2014-12-05 | 2 |  |  |  | 34.66d |  | Корректор; Бумага писчая [1 пачка] | 29.36h | 4,504 |  |
| 19 | 2.2 | Корр_Статья 2 | 2.67d | 2014-11-20 | 2014-11-24 | 3 |  |  |  | 43.66d |  | Корректор; Бумага писчая [1 пачка] | 21.36h | 3,304 |  |
| 20 | 2.3 | Корр_Статья 3 | 4d | 2014-12-17 | 2014-12-22 | 4 |  |  |  | 23.33d |  | Корректор; Бумага писчая [1 пачка] | 32h | 4,900 |  |
| 21 | 2.4 | Корр_Статья 4 | 1d | 2014-12-11 | 2014-12-11 | 5 |  |  |  | 30.33d |  | Корректор; Бумага писчая [1 пачка] | 8h | 1,300 |  |
| 22 | 2.5 | Корр_Статья 5 | 5d | 2014-12-01 | 2014-12-11 | 6 |  |  |  | 30.99d |  | Корректор; Бумага писчая [1 пачка] | 40h | 6,100 |  |
| 23 | 2.6 | Корр_Статья 6 | 1.33d | 2014-12-30 | 2015-01-12 | 7 |  |  |  | 17d |  | Корректор; Бумага писчая [1 пачка] | 10.64h | 1,696 |  |
| 24 | 2.7 | Корр_Статья 7 | 1.67d | 2014-12-24 | 2014-12-25 | 8 |  |  |  | 20.66d |  | Корректор; Бумага писчая [1 пачка] | 13.36h | 2,104 |  |
| 25 | 2.8 | Корр_Статья 8 | 0.67d | 2014-12-04 | 2014-12-04 | 9 |  |  |  | 35.66d |  | Корректор; Бумага писчая [1 пачка] | 5.36h | 904 |  |
| 26 | 2.9 | Корр_Статья 9 | 0.33d | 2014-12-03 | 2014-12-03 | 10 |  |  |  | 37d |  | Корректор; Бумага писчая [1 пачка] | 2.64h | 496 |  |
| 27 | 2.10 | Корр_Статья 10 | 1.33d | 2014-11-26 | 2014-11-27 | 11 |  |  |  | 41d |  | Корректор; Бумага писчая [1 пачка] | 10.64h | 1,696 |  |
| 28 | 2.11 | Корр_Статья 11 | 0.67d | 2014-12-02 | 2014-12-02 | 12 |  |  |  | 37.66d |  | Корректор; Бумага писчая [1 пачка] | 5.36h | 904 |  |
| 29 | 2.12 | Корр_Статья 12 | 1.67d | 2014-11-17 | 2014-11-18 | 13 |  |  |  | 47.66d |  | Корректор; Бумага писчая [1 пачка] | 13.36h | 2,104 |  |
| 30 | 2.13 | Корр_Статья 13 | 2.33d | 2015-02-02 | 2015-02-04 | 14 |  |  |  | 0d |  | Корректор; Бумага писчая [1 пачка] | 18.64h | 2,896 |  |
| 31 | 2.14 | Корр_Статья 14 | 3.67d | 2014-12-08 | 2014-12-12 | 15 |  |  |  | 29.91d |  | Корректор; Бумага писчая [1 пачка] | 29.36h | 4,504 |  |
| 32 | 2.15 | Корр_Статья 15 | 3d | 2015-01-13 | 2015-01-15 | 16 |  |  |  | 13.33d |  | Корректор; Бумага писчая [1 пачка] | 24h | 3,700 |  |
| 33 | 3 | Верстка | 11d | 2015-02-04 | 2015-02-19 | 17 |  |  |  | 0d |  | Сергеев | 88h | 11,000 |  |
| 34 | 4 | Обложка | 6d | 2015-02-02 | 2015-02-09 | 1 |  |  |  | 13.33d |  | Художник [0.1%]; Федоров [50%]; Почтовые расходы [0.1%] | 24h | 8,400 |  |
| 35 | 5 | Печать | 6d | 2015-02-19 | 2015-03-02 | 33 |  |  |  | 0d |  | Типография; Федоров [50%]; Бумага типографская [300 пачка]; Почтовые расходы [0.1%] | 8h | 51,800 |  |
